# PPM-Implementierung

Schedule from MS Project, 2013-07-19 to 2013-10-14.
Implementierung eines unternehmensweiten Projektm
holert.com

## Calendars

- Standard: Mon-Fri 08:00-12:00, 13:00-17:00; Sat-Sun off.

## Resources

| Resource |
| --- |
| Berater |
| Trainer |

## Schedule

| ID | WBS | Task | Type | Duration | Start | Finish | Predecessors | Total slack | Free slack | Resources | Work |
| --- | --- | --- | --- | --- | --- | --- | --- | --- | --- | --- | --- |
| 1 | 1 | **Definitionsphase** |  | 7d | 2013-07-19 | 2013-07-29 |  |  |  |  | 44h |
| 2 | 1.1 | Definitionsphase initiieren und planen |  | 1d | 2013-07-19 | 2013-07-19 |  | -1d | 0d | Berater | 8h |
| 3 | 1.2 | **Definitionsphase ausführen und steuern** |  | 5d | 2013-07-19 | 2013-07-25 | 2 |  |  |  | 32h |
| 4 | 1.2.1 | Kick-Off | milestone | 0d | 2013-07-19 | 2013-07-19 |  | 0d |  |  |  |
| 5 | 1.2.2 | Kick-Off-Workshop |  | 1d | 2013-07-22 | 2013-07-22 | 4 | 0d |  | Berater | 8h |
| 6 | 1.2.3 | Interviews mit Anwendern durchführen |  | 1d | 2013-07-23 | 2013-07-23 | 5 | 1d |  | Berater | 8h |
| 7 | 1.2.4 | Interviews mit Administratoren durchführen |  | 1d | 2013-07-24 | 2013-07-24 | 5 | 0d |  | Berater | 8h |
| 8 | 1.2.5 | Interviews auswerten |  | 1d | 2013-07-25 | 2013-07-25 | 7, 6 | 0d |  | Berater | 8h |
| 9 | 1.3 | Definitionsphase abschließen |  | 0.5d | 2013-07-26 | 2013-07-26 | 3 | 1.5d |  | Berater | 4h |
| 10 | 2 | **Entwurfsphase** |  | 9d | 2013-07-26 | 2013-08-07 | 1 |  |  |  | 68h |
| 11 | 2.1 | Entwurfsphase initiieren und planen |  | 1d | 2013-07-26 | 2013-07-29 |  | 4d | 0d | Berater | 8h |
| 12 | 2.2 | **Entwurfsphase ausführen und steuern** |  | 6d | 2013-07-29 | 2013-08-06 | 11 | 0d |  |  | 56h |
| 13 | 2.2.1 | PM-Prozesse entwerfen |  | 1d | 2013-07-29 | 2013-07-30 |  | 4d |  | Berater | 8h |
| 14 | 2.2.2 | Qualifizierungsprozesse entwerfen |  | 1d | 2013-07-29 | 2013-07-30 |  | 4d |  | Trainer | 8h |
| 15 | 2.2.3 | Project-Konfiguration entwerfen |  | 1d | 2013-07-30 | 2013-07-31 |  | 3d |  | Berater | 8h |
| 16 | 2.2.4 | Administrative Prozesse entwerfen |  | 1d | 2013-07-31 | 2013-08-01 |  | 2d |  | Berater | 8h |
| 17 | 2.2.5 | Bereitstellungsprozesse entwerfen |  | 1d | 2013-08-01 | 2013-08-02 |  | 1d |  | Berater | 8h |
| 18 | 2.2.6 | Bereitstellungswerkzeuge entwerfen |  | 1d | 2013-08-02 | 2013-08-05 |  | 0d |  | Berater | 8h |
| 19 | 2.2.7 | Feedback für die Entwurfsphase einholen |  | 1d | 2013-08-05 | 2013-08-06 | 13, 14, 15, 16, 17, 18 | 0d |  | Berater | 8h |
| 20 | 2.3 | Entwurfsphase abschließen |  | 0.5d | 2013-08-07 | 2013-08-07 | 12 | 0d |  | Berater | 4h |
| 21 | 2.4 | Entwurf fertigstellen | milestone | 0d | 2013-08-07 | 2013-08-07 | 20 | 0d |  |  |  |
| 22 | 3 | **Prototypphase** |  | 10d | 2013-08-05 | 2013-08-16 | 10 |  |  |  | 68h |
| 23 | 3.1 | Prototypphase initiieren und planen |  | 1d | 2013-08-06 | 2013-08-07 |  | 0d |  | Berater | 8h |
| 24 | 3.2 | **Prototypphase ausführen und steuern** |  | 7d | 2013-08-07 | 2013-08-16 | 23 | 0d |  |  | 56h |
| 25 | 3.2.1 | Prototyp-Administratoren qualifizieren |  | 1d | 2013-08-07 | 2013-08-08 |  | 0d |  | Trainer | 8h |
| 26 | 3.2.2 | Bereitstellungswerkzeuge für den Prototyp anpassen |  | 1d | 2013-08-08 | 2013-08-09 | 25 | 0d |  | Berater | 8h |
| 27 | 3.2.3 | Prototyp bereitstellen |  | 1d | 2013-08-09 | 2013-08-12 | 26 | 0d |  | Berater | 8h |
| 28 | 3.2.4 | Administrative Prozesse am Prototyp ausführen |  | 1d | 2013-08-12 | 2013-08-13 | 27 | 0d |  | Berater | 8h |
| 29 | 3.2.5 | Project-Prototyp konfigurieren |  | 1d | 2013-08-13 | 2013-08-14 | 28 | 0d |  | Berater | 8h |
| 30 | 3.2.6 | Prototyp-Anwender qualifizieren |  | 1d | 2013-08-14 | 2013-08-15 | 29 | 0d |  | Trainer | 8h |
| 31 | 3.2.7 | Feedback für Prototypphase einholen |  | 1d | 2013-08-15 | 2013-08-16 | 30 | 0d |  | Berater | 8h |
| 32 | 3.3 | Prototypphase abschließen |  | 0.5d | 2013-08-16 | 2013-08-16 | 24 | 0d |  | Berater | 4h |
| 33 | 3.4 | Prototyp fertigstellen | milestone | 0d | 2013-08-16 | 2013-08-16 | 32 | 0d |  |  |  |

| ID | WBS | Task | Type | Duration | Start | Finish | Predecessors | Total slack | Free slack | Resources | Work |
| --- | --- | --- | --- | --- | --- | --- | --- | --- | --- | --- | --- |
| 34 | 4 | **Pilotphase** |  | 18d | 2013-08-17 | 2013-09-10 | 22 |  |  |  | 116h |
| 35 | 4.1 | Pilotphase initiieren und planen |  | 1d | 2013-08-19 | 2013-08-19 |  | 16d |  | Berater | 8h |
| 36 | 4.2 | **Pilotphase ausführen und steuern** |  | 16d | 2013-08-19 | 2013-09-09 |  | 0.5d |  |  | 104h |
| 37 | 4.2.1 | Pilot-Administratoren qualifizieren |  | 1d | 2013-08-19 | 2013-08-19 |  | 0.5d | 0d | Trainer | 8h |
| 38 | 4.2.2 | Bereitstellungswerkzeuge für das Pilotsystem anpassen |  | 1d | 2013-08-20 | 2013-08-20 | 37 | 0.5d | 0d | Berater | 8h |
| 39 | 4.2.3 | Pilotsystem bereitstellen |  | 1d | 2013-08-21 | 2013-08-21 | 38 | 0.5d | 0d | Berater | 8h |
| 40 | 4.2.4 | Administrative Prozesse am Pilotsystem ausführen |  | 1d | 2013-08-22 | 2013-08-22 | 39 | 0.5d | 0d | Berater | 8h |
| 41 | 4.2.5 | Project-Pilotsystem konfigurieren |  | 1d | 2013-08-23 | 2013-08-23 | 40 | 0.5d | 0d | Berater | 8h |
| 42 | 4.2.6 | Pilot-Anwender qualifizieren |  | 1d | 2013-08-26 | 2013-08-26 | 41 | 0.5d | 0d | Trainer | 8h |
| 43 | 4.2.7 | **Pilottests** |  | 10d | 2013-08-26 | 2013-09-09 | 42 | 0.5d | 0d |  | 48h |
| 44 | 4.2.7.1 | Pilottest starten | milestone | 0d | 2013-08-26 | 2013-08-26 |  | 0.5d | 0d |  |  |
| 45 | 4.2.7.2 | Pilottest durchführen |  | 2w | 2013-08-27 | 2013-09-09 | 44 | 0.5d | 0d |  |  |
| 46 | 4.2.7.3 | Anwender unterstützen |  | 1d | 2013-09-03 | 2013-09-03 | 45SS+1w | 4.5d |  | Trainer | 8h |
| 47 | 4.2.7.4 | Administratoren unterstützen |  | 1d | 2013-09-04 | 2013-09-04 | 45SS+1w | 3.5d |  | Trainer | 8h |
| 48 | 4.2.7.5 | **Pilotsystem optimieren** |  | 3d | 2013-09-03 | 2013-09-05 | 45SS+1w | 2d | 0d |  | 32h |
| 49 | 4.2.7.5.1 | Administrative Prozesse überarbeiten |  | 1d | 2013-09-03 | 2013-09-03 |  | 4d |  | Berater | 8h |
| 50 | 4.2.7.5.2 | Project-Konfiguration überarbeiten |  | 1d | 2013-09-04 | 2013-09-04 |  | 3d |  | Berater | 8h |
| 51 | 4.2.7.5.3 | PM-Prozesse überarbeiten |  | 1d | 2013-09-05 | 2013-09-05 |  | 2d |  | Berater | 8h |
| 52 | 4.2.7.5.4 | Qualifizierungsprozesse überarbeiten |  | 1d | 2013-09-05 | 2013-09-05 |  | 2d |  | Trainer | 8h |
| 53 | 4.2.8 | Feedback einholen und ggf. Pilottest neu starten |  | 1d | 2013-09-06 | 2013-09-06 | 48 | 2d |  | Berater | 8h |
| 54 | 4.3 | Pilotphase abschließen |  | 0.5d | 2013-09-10 | 2013-09-10 | 43 | 0.5d | 0d | Berater | 4h |
| 55 | 4.4 | Pilottest abschließen | milestone | 0d | 2013-09-10 | 2013-09-10 | 54 | 0.5d |  |  |  |
| 56 | 5 | **Einführungsphase** |  | 12.5d | 2013-09-09 | 2013-09-25 | 34 |  |  |  | 100h |
| 57 | 5.1 | Einführungsphase initiieren und planen |  | 1d | 2013-09-09 | 2013-09-09 |  | 0d |  | Berater | 8h |

| ID | WBS | Task | Type | Duration | Start | Finish | Predecessors | Total slack | Resources | Work |
| --- | --- | --- | --- | --- | --- | --- | --- | --- | --- | --- |
| 58 | 5.2 | **Einführungsphase ausführen und steuern** |  | 11d | 2013-09-10 | 2013-09-24 | 57 | 0d |  | 88h |
| 59 | 5.2.1 | Administratoren qualifizieren |  | 1d | 2013-09-10 | 2013-09-10 |  | 0d | Trainer | 8h |
| 60 | 5.2.2 | Bereitstellungswerkzeuge anpassen |  | 1d | 2013-09-11 | 2013-09-11 | 59 | 0d | Berater | 8h |
| 61 | 5.2.3 | Produktivsystem bereitstellen |  | 1d | 2013-09-12 | 2013-09-12 | 60 | 0d | Berater | 8h |
| 62 | 5.2.4 | Administrative Prozesse ausführen |  | 1d | 2013-09-13 | 2013-09-13 | 61 | 0d | Berater | 8h |
| 63 | 5.2.5 | Project konfigurieren |  | 1d | 2013-09-16 | 2013-09-16 | 62 | 0d | Berater | 8h |
| 64 | 5.2.6 | Anwender qualifizieren |  | 5d | 2013-09-17 | 2013-09-23 | 63 | 0d | Trainer | 40h |
| 65 | 5.2.7 | Feedback zur Einführungsphase einholen |  | 1d | 2013-09-24 | 2013-09-24 | 64 | 0d | Berater | 8h |
| 66 | 5.2.8 | Produktivbetrieb aufnehmen | milestone | 0d | 2013-09-24 | 2013-09-24 | 65 | 0d |  |  |
| 67 | 5.3 | Einführungsphase abschließen |  | 0.5d | 2013-09-25 | 2013-09-25 | 58 | 0d | Berater | 4h |
| 68 | 6 | **Optimierungsphase** |  | 11.5d | 2013-09-27 | 2013-10-14 | 56 |  |  | 68h |
| 69 | 6.1 | Optimierungsphase initiieren und planen |  | 1d | 2013-09-27 | 2013-09-27 |  | 0d | Berater | 8h |
| 70 | 6.2 | **Optimierungsphase ausführen und steuern** |  | 10d | 2013-09-30 | 2013-10-11 | 69 | 0d |  | 56h |
| 71 | 6.2.1 | Produktion |  | 2w | 2013-09-30 | 2013-10-11 |  | 0d |  |  |
| 72 | 6.2.2 | Feedback zur Optimierungsphase einholen |  | 1d | 2013-09-30 | 2013-09-30 |  | 9d | Berater | 8h |
| 73 | 6.2.3 | Ggf. PM-Prozesse optimieren |  | 1d | 2013-10-01 | 2013-10-01 |  | 8d | Berater | 8h |
| 74 | 6.2.4 | Ggf. Qualifizierungsprozesse optimieren |  | 1d | 2013-09-30 | 2013-09-30 |  | 9d | Trainer | 8h |
| 75 | 6.2.5 | Ggf. Administratoren nachqualifizieren |  | 1d | 2013-10-01 | 2013-10-01 |  | 8d | Trainer | 8h |
| 76 | 6.2.6 | Ggf. Anwender nachqualifizieren |  | 1d | 2013-10-02 | 2013-10-02 |  | 7d | Trainer | 8h |
| 77 | 6.2.7 | Ggf. Project-Konfiguration optimieren |  | 1d | 2013-10-02 | 2013-10-02 |  | 7d | Berater | 8h |
| 78 | 6.2.8 | Ggf. administrative Prozesse optimieren |  | 1d | 2013-10-03 | 2013-10-03 |  | 6d | Berater | 8h |
| 79 | 6.3 | Optimierungsphase abschließen |  | 0.5d | 2013-10-14 | 2013-10-14 | 70 | 0d | Berater | 4h |
