# Kap11_02

Schedule from MS Project, 2013-04-24 to 2013-06-03.
holert.com

## Calendars

- Standard: Mon-Fri 08:00-12:00, 13:00-17:00; Sat-Sun off.

## Resources

| Resource |
| --- |
| Arne Zwirner |
| Fred Foster |
| Peter Peterson |
| Renke Holert |
| Tim Turner |

## Schedule

| ID | WBS | Task | Type | Duration | Start | Finish | Predecessors | Total slack | Resources | Work |
| --- | --- | --- | --- | --- | --- | --- | --- | --- | --- | --- |
| 1 | 1 | **Initialisierung** |  | 2d | 2013-04-24 | 2013-04-25 |  | 0d |  | 16h |
| 2 | 1.1 | Auftrag erteilt | milestone | 0d | 2013-04-24 | 2013-04-24 |  | 0d |  |  |
| 3 | 1.2 | Marketingkonzept erstellen |  | 2d | 2013-04-24 | 2013-04-25 | 2 | 0d | Arne Zwirner | 16h |
| 4 | 2 | **Entwurf Prototyp** |  | 6d | 2013-04-26 | 2013-05-03 |  | 0d |  | 64h |
| 5 | 2.1 | Designkonzept |  | 2d | 2013-04-26 | 2013-04-29 | 3 | 0d | Fred Foster | 16h |
| 6 | 2.2 | Navigationskonzept |  | 2d | 2013-04-30 | 2013-05-01 | 5 | 0d | Peter Peterson | 16h |
| 7 | 2.3 | Implementationskonzept |  | 1d | 2013-05-02 | 2013-05-02 | 6 | 0d | Renke Holert | 8h |
| 8 | 2.4 | Betriebskonzept |  | 1d | 2013-05-02 | 2013-05-02 | 7SS | 0d | Peter Peterson | 8h |
| 9 | 2.5 | Konzeptpräsentation |  | 1d | 2013-05-03 | 2013-05-03 | 7, 8 | 0d | Tim Turner; Peter Peterson | 16h |
| 10 | 2.6 | Abnahme Prototyp | milestone | 0d | 2013-05-03 | 2013-05-03 | 9 | 0d |  |  |
| 11 | 3 | **Realisierung** |  | 17d | 2013-05-06 | 2013-05-28 |  | 0d |  | 336h |
| 12 | 3.1 | ToDo Liste erstellen |  | 1d | 2013-05-06 | 2013-05-06 | 10 | 0d | Renke Holert | 8h |
| 13 | 3.2 | Inhalte erstellen |  | 15d | 2013-05-07 | 2013-05-27 | 12 | 1d | Peter Peterson | 120h |
| 14 | 3.3 | Programmierung |  | 13d | 2013-05-10 | 2013-05-28 | 12FS+3d | 0d | Fred Foster; Tim Turner | 208h |
| 15 | 3.4 | Website erstellt | milestone | 0d | 2013-05-28 | 2013-05-28 | 13, 14 | 0d |  |  |
| 16 | 4 | **Abnahme** |  | 3.5d | 2013-05-29 | 2013-06-03 |  | 0d |  | 36h |
| 17 | 4.1 | Abnahmedokument |  | 1d | 2013-05-29 | 2013-05-29 | 15 | 0d | Peter Peterson | 8h |
| 18 | 4.2 | Testlauf |  | 1d | 2013-05-30 | 2013-05-30 | 17 | 0d | Fred Foster; Tim Turner | 16h |
| 19 | 4.3 | Fehlerbehebung |  | 1d | 2013-05-31 | 2013-05-31 | 18 | 0d | Tim Turner | 8h |
| 20 | 4.4 | Liveschaltung der Website |  | 0.5d | 2013-06-03 | 2013-06-03 | 19 | 0d | Peter Peterson | 4h |
| 21 | 4.5 | Projektabschluss | milestone | 0d | 2013-06-03 | 2013-06-03 | 20 | 0d |  |  |
