# Kap11_06

Schedule from MS Project, 2013-07-01 to 2013-10-18, costs in €.
holert.com

## Calendars

- Standard: Mon-Fri 08:00-12:00, 13:00-17:00; Sat-Sun off.

## Resources

| Resource | Group | Rate |
| --- | --- | --- |
| Arne Zwirner |  | 100 |
| Fred Foster | Hochbau | 100 |
| Peter Peterson | Tiefbau | 100 |
| Renke Holert |  | 100 |
| Tim Turner | Tiefbau | 100 |

## Schedule

| ID | WBS | Task | Type | Duration | Start | Finish | Predecessors | Constraint | Resources | Work | Cost |
| --- | --- | --- | --- | --- | --- | --- | --- | --- | --- | --- | --- |
| 1 | 1 | **Initialisierung** |  | 2d | 2013-07-01 | 2013-07-02 |  |  |  | 16h | 1,600 |
| 2 | 1.1 | Auftrag erteilt | milestone, manual | 0d | 2013-07-01 | 2013-07-01 |  |  |  |  |  |
| 3 | 1.2 | Marketingkonzept erstellen | manual | 2d | 2013-07-01 | 2013-07-02 | 2 |  | Arne Zwirner | 16h | 1,600 |
| 4 | 2 | **Entwurf Prototyp** |  | 44d | 2013-07-03 | 2013-09-02 |  |  |  | 276h | 27,600 |
| 5 | 2.1 | Designkonzept | manual | 19.5d | 2013-07-03 | 2013-08-14 | 3 |  | Fred Foster | 156h | 15,600 |
| 6 | 2.2 | Navigationskonzept | manual | 11d | 2013-08-15 | 2013-08-29 | 5 | start no earlier than 2013-08-15 | Peter Peterson | 88h | 8,800 |
| 7 | 2.3 | Implementationskonzept | manual | 1d | 2013-08-30 | 2013-08-30 | 6 | start no earlier than 2013-08-30 | Renke Holert | 8h | 800 |
| 8 | 2.4 | Betriebskonzept | manual | 1d | 2013-08-30 | 2013-08-30 | 7SS |  | Peter Peterson | 8h | 800 |
| 9 | 2.5 | Konzeptpräsentation | manual | 1d | 2013-09-02 | 2013-09-02 | 7, 8 |  | Tim Turner; Peter Peterson | 16h | 1,600 |
| 10 | 2.6 | Abnahme Prototyp | milestone, manual | 0d | 2013-09-02 | 2013-09-02 | 9 |  |  |  |  |
| 11 | 3 | **Realisierung** |  | 31d | 2013-09-03 | 2013-10-15 |  |  |  | 576h | 57,600 |
| 12 | 3.1 | ToDo Liste erstellen | manual | 1d | 2013-09-03 | 2013-09-03 | 10 |  | Renke Holert | 8h | 800 |
| 13 | 3.2 | Inhalte erstellen | manual | 15d | 2013-09-04 | 2013-09-24 | 12 |  | Peter Peterson; Tim Turner; Arne Zwirner | 360h | 36,000 |
| 14 | 3.3 | Programmierung | manual | 25d | 2013-09-09 | 2013-10-11 | 12FS+3d |  | Fred Foster; Tim Turner | 208h | 20,800 |
| 15 | 3.4 | Website erstellt | milestone, manual | 0d | 2013-10-14 | 2013-10-14 | 13, 14 |  |  |  |  |
| 16 | 4 | **Abnahme** |  | 5d | 2013-10-14 | 2013-10-18 |  |  |  | 36h | 3,600 |
| 17 | 4.1 | Abnahmedokument | manual | 1d | 2013-10-14 | 2013-10-14 | 15 |  | Peter Peterson | 8h | 800 |
| 18 | 4.2 | Testlauf | manual | 1d | 2013-10-15 | 2013-10-15 | 17 |  | Fred Foster; Tim Turner | 16h | 1,600 |
| 19 | 4.3 | Fehlerbehebung | manual | 1d | 2013-10-16 | 2013-10-16 | 18 |  | Tim Turner | 8h | 800 |
| 20 | 4.4 | Liveschaltung der Website | manual | 0.5d | 2013-10-17 | 2013-10-17 | 19 |  | Peter Peterson | 4h | 400 |
| 21 | 4.5 | Projektabschluss | milestone, manual | 0d | 2013-10-17 | 2013-10-17 | 20 |  |  |  |  |
